# MSTF tripod

Schedule from MS Project, 2010-09-01 to 2011-01-05.
MBARI

## Calendars

- Standard: Mon-Fri 08:00-12:00, 13:00-17:00; Sat-Sun off.

## Resources

| Resource |
| --- |
| Lance |
| Brett |
| Thomas |
| Machine shop |
| Jon |
| Lance McBride |
| Thomas Hoover |
| Test Tank |
| Rob Mcewen |
| Zephyr |
| Brett Hobson |
| Jon Erickson |
| AUV Fabricator #1 |
| Mike Godin |
| Yanwu Zhang |
| Rich |
| EE |
| SE |
| ME |
| MS |
| RE |
| ET |
| MT |
| Jake |
| Alana |
| SRVI |
| Larry |
| Johnny |
| MSTF |

## Schedule

| ID | WBS | Task | Type | Duration | Start | Finish | Predecessors | Total slack | Free slack | Constraint | Resources | Work |
| --- | --- | --- | --- | --- | --- | --- | --- | --- | --- | --- | --- | --- |
| 1 | 1 | **MSTF Carbon Cycling Camera System** |  | 91d? | 2010-09-01 | 2011-01-05 |  | 0d |  |  |  | 1464h |
| 2 | 1.1 | **Structure** |  | 21d | 2010-09-01 | 2010-09-29 |  | 49.5d |  |  |  | 96h |
| 3 | 1.1.1 | **Tripod** |  | 21d | 2010-09-01 | 2010-09-29 |  | 49.5d |  |  |  | 96h |
| 4 | 1.1.1.1 | modify quad frame |  | 5d | 2010-09-01 | 2010-09-07 |  | 49.5d | 0d |  | Larry | 40h |
| 5 | 1.1.1.2 | add supports for acoustic release |  | 12d | 2010-09-08 | 2010-09-23 | 4 | 49.5d | 0d |  | Brett [25%] | 24h |
| 6 | 1.1.1.3 | design and fabricate weight drop |  | 1d | 2010-09-24 | 2010-09-24 | 5 | 49.5d | 0d |  | Larry | 8h |
| 7 | 1.1.1.4 | new lifting eye and frame |  | 1d | 2010-09-27 | 2010-09-27 | 6 | 70d | 0d |  | Larry | 8h |
| 8 | 1.1.1.5 | fabricate drop weights |  | 1d | 2010-09-28 | 2010-09-28 | 7 | 70d | 0d |  | Johnny | 8h |
| 9 | 1.1.1.6 | mooring float assemblies |  | 1d | 2010-09-29 | 2010-09-29 | 8 | 70d |  |  | Jake | 8h |
| 10 | 1.2 | **Spar buoy assembly** |  | 3d | 2010-09-01 | 2010-09-03 |  | 88d |  |  |  | 32h |
| 11 | 1.2.1 | order Strobe, RF beacon |  | 1d | 2010-09-01 | 2010-09-01 |  | 88d | 0d |  | Jake | 8h |
| 12 | 1.2.2 | order mast material |  | 1d | 2010-09-02 | 2010-09-02 | 11 | 88d | 0d |  | Jake | 8h |
| 13 | 1.2.3 | build up mast |  | 0.5d | 2010-09-03 | 2010-09-03 | 12 | 88d | 0d |  | Jake; Johnny | 8h |
| 14 | 1.2.4 | locate and install mast float |  | 0.5d | 2010-09-03 | 2010-09-03 | 13 | 88d |  |  | Jake; Johnny | 8h |
| 15 | 1.3 | **Camera System** |  | 91d? | 2010-09-01 | 2011-01-05 |  | 0d |  |  |  | 1072h |
| 16 | 1.3.1 | specify camera |  | 2d | 2010-09-08 | 2010-09-09 |  | 81d | 0d | start no earlier than 2010-09-08 | Brett [25%] | 4h |
| 17 | 1.3.2 | order camera equipment |  | 3d | 2010-09-10 | 2010-09-14 | 16 | 81d | 0d | finish no earlier than 2005-09-19 | MSTF | 24h |
| 18 | 1.3.3 | Camera equipment to arrive at MBARI | milestone | 0d | 2010-09-14 | 2010-09-14 | 17 | 81d |  |  | MSTF |  |
| 19 | 1.3.4 | **Electronics** |  | 37d | 2010-09-01 | 2010-10-21 |  | 54d |  |  |  | 74h |
| 20 | 1.3.4.1 | Circuit diagram |  | 5d | 2010-09-01 | 2010-09-07 |  | 54d | 0d |  | Alana [25%] | 10h |
| 21 | 1.3.4.2 | order connectors |  | 4d | 2010-09-08 | 2010-09-13 | 20 | 54d | 0d |  | Alana [25%] | 8h |
| 22 | 1.3.4.3 | get TT3 working |  | 16d | 2010-09-14 | 2010-10-05 | 21 | 54d | 0d |  | Alana [25%] | 32h |
| 23 | 1.3.4.4 | layout new control board |  | 4d | 2010-10-06 | 2010-10-11 | 22 | 54d | 0d |  | Alana [25%] | 8h |
| 24 | 1.3.4.5 | build up connecting cables |  | 4d | 2010-10-12 | 2010-10-15 | 23 | 54d | 0d |  | Alana [25%] | 8h |
| 25 | 1.3.4.6 | modify camera mount for D700 |  | 4d | 2010-10-18 | 2010-10-21 | 24 | 54d |  |  | Alana [25%] | 8h |

| ID | WBS | Task | Type | Duration | Start | Finish | Predecessors | Total slack | Free slack | Resources | Work |
| --- | --- | --- | --- | --- | --- | --- | --- | --- | --- | --- | --- |
| 26 | 1.3.5 | **Battery housing** |  | 52d? | 2010-09-01 | 2010-11-11 |  | 0d |  |  | 626h |
| 27 | 1.3.5.1 | Design Li primary pack |  | 13d | 2010-09-01 | 2010-09-17 |  | 16d | 0d | Brett [25%] | 26h |
| 28 | 1.3.5.2 | Battery Pack ordered | milestone | 0d | 2010-09-17 | 2010-09-17 | 27 | 78d |  |  |  |
| 29 | 1.3.5.3 | Order battery pack |  | 35d | 2010-09-20 | 2010-11-05 | 27 | 16d | 0d | MSTF | 280h |
| 30 | 1.3.5.4 | get quotes from third party housing fab |  | 4d? | 2010-09-01 | 2010-09-06 |  | 0d |  | Brett [25%] | 8h |
| 31 | 1.3.5.5 | Design new housing |  | 4d? | 2010-09-07 | 2010-09-10 | 30 | 0d |  | Brett [25%] | 8h |
| 32 | 1.3.5.6 | generate machine prints |  | 4d? | 2010-09-13 | 2010-09-16 | 31 | 0d |  | Brett [25%] | 8h |
| 33 | 1.3.5.7 | work with Don on housing mfg. |  | 4d? | 2010-09-17 | 2010-09-22 | 32 | 0d |  | Brett [25%] | 8h |
| 34 | 1.3.5.8 | manufacture battery housing |  | 35d | 2010-09-23 | 2010-11-10 | 33 | 0d |  | MSTF | 280h |
| 35 | 1.3.5.9 | Start Battery Housing | milestone | 0d | 2010-09-22 | 2010-09-22 | 33 | 35d |  |  |  |
| 36 | 1.3.5.10 | Deliver battery housing to MBARI | milestone | 0d | 2010-11-10 | 2010-11-10 | 34, 35 | 0d |  | MSTF |  |
| 37 | 1.3.5.11 | Batteries to arrive at MBARI | milestone | 0d | 2010-11-10 | 2010-11-10 | 36 | 40d |  | MSTF |  |
| 38 | 1.3.5.12 | assemble and test battery system |  | 4d? | 2010-11-08 | 2010-11-11 | 29 | 16d | 0d | Alana [25%] | 8h |
| 39 | 1.3.6 | **Replacement camera housing** |  | 91d | 2010-09-01 | 2011-01-05 |  | 0d |  |  | 344h |
| 40 | 1.3.6.1 | update design |  | 7d | 2010-09-01 | 2010-09-09 |  | 39d | 0d | Brett [25%] | 14h |
| 41 | 1.3.6.2 | generate machine prints |  | 5d | 2010-09-10 | 2010-09-16 | 40 | 39d |  | Brett [25%] | 10h |
| 42 | 1.3.6.3 | manufacture camera housing |  | 40d | 2010-11-11 | 2011-01-05 | 41, 36 | 0d |  | MSTF | 320h |
| 43 | 1.3.6.4 | Deliver camera housing to MBARI | milestone | 0d | 2011-01-05 | 2011-01-05 | 42 | 0d |  | MSTF |  |
| 44 | 1.4 | **Test and integration** |  | 42d? | 2010-09-27 | 2010-11-23 |  | 16d |  |  | 136h |
| 45 | 1.4.1 | test camera system with P/S |  | 0.5d? | 2010-09-27 | 2010-09-27 | 6 | 49.5d | 33.5d | Alana; Brett | 8h |
| 46 | 1.4.2 | integrate battery system |  | 2d | 2010-11-12 | 2010-11-15 | 45, 38, 36 | 16d | 0d | Alana; Brett | 32h |
| 47 | 1.4.3 | cold room testing |  | 1d | 2010-11-16 | 2010-11-16 | 46 | 16d | 0d | Alana; Brett | 16h |
| 48 | 1.4.4 | tank testing and burn-in |  | 5d | 2010-11-17 | 2010-11-23 | 47 | 16d | 0d | Alana; Brett | 80h |
| 49 | 1.5 | install in shipping container |  | 1d | 2010-11-24 | 2010-11-24 | 48 | 16d | 0d | Alana; Brett | 16h |
| 50 | 1.6 | Container leaves MBARI | milestone | 0d | 2010-11-24 | 2010-11-24 | 49 | 16d | 0d |  |  |
| 51 | 1.7 | ship to Bermuda |  | 14d | 2010-11-25 | 2010-12-14 | 50 | 16d | 0d | MSTF | 112h |
| 52 | 1.8 | Arrives in Bermuda | milestone | 0d | 2010-12-14 | 2010-12-14 | 51 | 16d |  |  |  |
